# Injector PS Schedule

Schedule from MS Project, 2005-08-01 to 2006-06-12, costs in $, A marks actual dates.
Stanford Linear Accelerator Center

## Calendars

- Standard: Mon-Fri 08:00-12:00, 13:00-17:00; Sat-Sun off.

## Resources

| Resource | Group | Rate | Notes |
| --- | --- | --- | --- |
| Engineer | CPEE | 108.8 | From SLAC 2004 Skill Rate Spreadsheet / $80/hour * 1.36 burden = $108.80/hr |
| Coordinator | CPEC | 78.88 | From SLAC 2004 Skill Rate Spreadsheet / $58/hour * 1.36 burden = $78.88/hr |
| Technician | CPET | 61.2 | From SLAC 2004 Skill Rate Spreadsheet / $45/hour * 1.36 burden = $61.20/hr |
| By others | Other |  |  |

## Schedule

| ID | WBS | Task | Type | Duration | Start | Finish | Predecessors | Complete | Remaining | Total slack | Free slack | Constraint | Resources | Work | Actual work | Cost | Actual cost |
| --- | --- | --- | --- | --- | --- | --- | --- | --- | --- | --- | --- | --- | --- | --- | --- | --- | --- |
| 1 | 1 | **Summary** |  | 226d? | 2005-08-01 A | 2006-06-12 |  | 62% | 85.31d? | 0d |  |  |  | 3296.4h | 1858.14h | 385,206.15 | 36,508 |
| 2 | 1.1 | Start | milestone | 0d | 2005-08-01 | 2005-08-01 |  |  |  | 148d | 70d |  |  |  |  |  |  |
| 3 | 1.2 | Drawing numbers |  | 1w | 2005-08-01 A | 2005-08-05 A | 2 | 100% |  |  |  |  | Engineer |  |  |  |  |
| 4 | 1.3 | Coordinate Racks |  | 5w | 2005-08-29 A | 2005-09-30 A | 2 | 100% |  |  |  | start no earlier than 2005-08-28 | Coordinator [5%] | 10h | 10h | 788.8 | 788.8 |
| 5 | 1.4 | Define installation & field tests |  | 8w | 2005-11-07 | 2005-12-30 | 2 |  |  | 106d |  | start no earlier than 2005-11-06 | Engineer [20%] | 64h |  | 6,963.2 |  |
| 6 | 1.5 | Magnet list/ EI diagrams |  | 9w | 2005-08-01 A | 2005-09-30 A | 2 | 100% |  |  |  |  | Coordinator [20%] | 72h | 72h | 5,679.36 | 5,679.36 |
| 7 | 1.6 | Rack front view |  | 2w | 2005-09-19 A | 2005-09-30 A | 2 | 100% |  |  |  | start no earlier than 2005-09-18 | Coordinator [25%] | 20h | 20h | 1,577.6 | 1,577.6 |
| 8 | 1.7 | Rack AC distribution |  | 3w | 2005-10-03 A | 2005-10-21 A | 2 | 100% |  |  |  | start no earlier than 2005-10-02 | By others | 120h | 120h |  |  |
| 9 | 1.8 | Specify VDAC, VSAM Hardware, Software |  | 12w | 2005-08-01 A | 2005-10-21 A | 2 | 100% |  |  |  |  | By others | 480h | 480h |  |  |
| 10 | 1.9 | MCOR12 EI review | milestone | 0d | 2005-09-30 | 2005-09-30 | 6 |  |  | 142.25d | 15d |  | Engineer [10%] |  |  |  |  |
| 11 | 1.10 | Order MCOR12s |  | 3w | 2005-10-03 A | 2005-10-21 A | 10 | 100% |  |  |  |  | Coordinator [25%] | 30h | 30h | 2,366.4 | 2,366.4 |
| 12 | 1.11 | MCOR12 delivery |  | 20.6w | 2005-10-24 A | 2006-03-15 | 11 | 85% | 3.09w | 2d | 0d | finish no earlier than 2006-03-15 | Coordinator [10%] | 82.4h | 70.04h | 168,152.71 | 5,524.76 |
| 13 | 1.12 | MCOR12 bench test procedure |  | 3w | 2005-10-03 A | 2005-10-21 A | 10 | 100% |  |  |  |  | Engineer [25%] | 30h | 30h | 3,264 | 3,264 |
| 14 | 1.13 | Bench Test MCORs |  | 5w | 2006-03-16 | 2006-04-19 | 13, 12 |  |  | 2d |  |  |  |  |  |  |  |
| 15 | 1.14 | Intermediate PS Controller Hardware, Software |  | 23w | 2005-10-24 A | 2006-03-31 | 10 | 75% | 5.75w | 41d | 10d | start no earlier than 2005-10-23 | By others | 920h | 690h | 17,120 |  |
| 16 | 1.15 | Write Intermediate PS spec |  | 4w | 2005-08-01 A | 2005-08-26 A | 2 | 100% |  |  |  |  | Engineer [40%] | 64h | 64h | 6,963.2 | 6,963.2 |
| 17 | 1.16 | Resolve PPS issue |  | 2w | 2005-08-01 A | 2005-08-12 A | 2 | 100% |  |  |  |  | Engineer [10%] | 8h | 8h | 870.4 | 870.4 |
| 18 | 1.17 | Intermediate PS design review | milestone | 0w | 2005-08-26 A | 2005-08-26 A | 16, 17 | 100% |  |  |  |  | Engineer |  |  |  |  |
| 19 | 1.18 | Order Intermediate power supplies |  | 3w | 2005-08-29 A | 2005-09-16 A | 18 | 100% |  |  |  |  | Coordinator [25%] | 30h | 30h | 2,366.4 | 2,366.4 |
| 20 | 1.19 | Intermediate PS, transductor dekivery |  | 26.5w | 2005-09-19 A | 2006-03-22 | 19 | 85% | 3.98w | 12.5d | 0d |  | Coordinator [10%] | 106h | 90.1h | 130,769.28 | 7,107.09 |
| 21 | 1.20 | Intermediate PS bench test procedure |  | 4w | 2005-08-29 | 2005-09-23 | 18 |  |  | 140d | 127.5d |  | Engineer [20%] | 32h |  | 3,481.6 |  |
| 22 | 1.21 | Bench Test Intermediate PS |  | 2w | 2006-03-22 | 2006-04-05 | 20, 21 |  |  | 12.5d |  |  |  |  |  |  |  |
| 23 | 1.22 | Rack delivery |  | 12w | 2006-01-30 A | 2006-04-21 | 2, 4 | 30% | 8.4w | 0d |  | start no earlier than 2006-01-29 | By others | 480h | 144h |  |  |
| 24 | 1.23 | Design AC power distribution |  | 5w | 2006-02-06 | 2006-03-10 | 4 |  |  | 25d | 0d | start no earlier than 2006-02-05 | Coordinator | 200h |  | 15,776 |  |
| 25 | 1.24 | Install AC distribution box |  | 1w | 2006-03-13 | 2006-03-17 | 24 |  |  | 25d |  |  | Technician [50%] | 20h |  | 1,224 |  |
| 26 | 1.25 | Install and wire MCORs into racks |  | 4w | 2006-04-24 | 2006-05-19 | 7, 8, 25, 23, 14 |  |  | 0d |  |  | Technician [30%] | 48h |  | 2,937.6 |  |
| 27 | 1.26 | Install and wire Intermediate PS into racks |  | 4w | 2006-04-24 | 2006-05-19 | 23, 20, 7, 8, 22 |  |  | 0d |  |  | Technician [20%] | 32h |  | 1,958.4 |  |
| 28 | 1.27 | Move racks to field |  | 0.2w? | 2006-05-22 | 2006-05-22 | 26, 27 |  |  | 0d |  |  |  |  |  |  |  |
| 29 | 1.28 | Connect AC to racks |  | 1w | 2006-05-23 | 2006-05-29 | 28 |  |  | 0d |  |  | By others | 40h |  |  |  |
| 30 | 1.29 | Pull DC power and control cables |  | 6w | 2006-03-06 | 2006-04-14 | 2 |  |  | 31d | 0d | start no earlier than 2006-03-05 | By others | 240h |  |  |  |
| 31 | 1.30 | Field test MCORs |  | 2w | 2006-05-30 | 2006-06-12 | 29, 30, 5, 9 |  |  | 0d |  |  | Engineer [50%]; Technician | 120h |  | 9,248 |  |
| 32 | 1.31 | Field test Intermediate PS |  | 2w | 2006-04-17 | 2006-04-28 | 30, 15 |  |  | 31d |  |  | Engineer [20%]; Technician [40%] | 48h |  | 3,699.2 |  |
| 33 | 1.32 | End | milestone | 0w | 2006-06-12 | 2006-06-12 | 3, 31, 32 |  |  | 0d |  |  |  |  |  |  |  |

Notes:
- 8: Coordinate with Mario Ortega
- 12: Based on Carl Rago's LCLS_LCLS_Magnet List_R4.xls. The above costs are for Material only
- 13: The MCOR12s are bench tested in the racks with the bulk power supplies
- 15: 8 power supply controllers @ $2,000 each = $16,000 / $16,000 * 1.07= $17,120
- 20: 11 power supplies each @$8000 each = $88,000 (Includes MCOR bulk power supplies) / 15 Transductors each $660 = $9900 / 2 transductor plates * $250 = $500 / Total cost = $89910*1.07=$95134
